# DPIC-PO-NEC-299-1002

Schedule from Primavera P6, 2021-08-11 to 2022-10-04, data date 2021-11-11.

## Calendars

- Standard: Mon-Sun 08:00-12:00, 13:00-17:00.

## Schedule

| ID | WBS | Activity | Type | Duration | Start | Finish | Predecessors | Planned start | Planned finish | Total float | Free float | % Plan for Report | % Actual for Report | % WF |
| --- | --- | --- | --- | --- | --- | --- | --- | --- | --- | --- | --- | --- | --- | --- |
|  | 1 | **DPIC-PO-NEC-299-1002** |  |  | 2021-08-11 | 2022-10-04 |  |  |  |  |  |  |  |  |
| 222 |  | Finish | milestone | 0d | 2022-10-04 | 2022-10-04 | 221 |  |  | 0d |  | 0 | 0 |  |
|  | 1 | **Milestones** |  |  | 2021-08-11 | 2021-08-11 |  |  |  |  |  |  |  |  |
| 3 |  | LOI Date | milestone | 0d | 2021-08-11 | 2021-08-11 |  |  |  | 0d |  | 0 | 0 |  |
| 4 |  | Effective Date | milestone | 0d | 2021-08-11 | 2021-08-11 | 3 |  |  | 0d |  | 0 | 0 |  |
| 5 |  | K.O.M | milestone | 0d | 2021-08-11 | 2021-08-11 | 4 |  |  | 0d |  | 0 | 0 |  |
| 6 |  | Bank Garanty Payment Date | milestone | 0d | 2021-08-11 | 2021-08-11 | 5 |  |  | 0d |  | 0 | 0 |  |
| 7 |  | Advanced Payment Date | milestone | 0d | 2021-08-11 | 2021-08-11 | 3, 6 |  |  | 0d |  | 0 | 0 |  |
|  | 2 | **Engineering** |  |  | 2021-08-15 | 2022-03-05 |  |  |  |  |  |  |  |  |
|  | 1 | **GENERAL DOCUMENT** |  |  | 2021-08-15 | 2021-12-19 |  |  |  |  |  |  |  |  |
| 10 |  | Vendor Print Index & Schedule (VPIS) | resource dependent | 21d | 2021-08-15 | 2021-09-04 | 7 FS+4d | 2021-08-16 | 2021-09-05 | 0d |  | 0.2 | 0.12 | 0.2 |
| 14 |  | Sub Vendor List | resource dependent | 21d | 2021-09-20 | 2021-10-10 | 10 FS+15d |  |  | 334d | 125d | 0.1 | 0.06 | 0.1 |
| 11 |  | WBS | resource dependent | 21d | 2021-09-25 | 2021-10-15 | 10 FS+20d |  |  | 178d | 0d | 0.1 | 0.1 | 0.1 |
| 12 |  | Time Schedule | resource dependent | 21d | 2021-11-08 | 2021-11-28 | 11 FS+23d |  |  | 264d | 0d | 0.00714285714285714 | 0 | 0.05 |
| 13 |  | Project Monthly Report for Refrigeration Packages | resource dependent | 21d | 2021-11-29 | 2021-12-19 | 12 |  |  | 264d | 55d | 0 | 0 | 0.05 |
|  | 2 | **ENGINEERING DOCUMENT** |  |  | 2021-10-17 | 2022-03-05 |  |  |  |  |  |  |  |  |
| 29 |  | Compressor Drawing | resource dependent | 21d | 2021-10-17 | 2021-11-06 | 34 SS |  |  | 35d | 0d | 0.05 | 0.03 | 0.05 |
| 34 |  | Process Flow Diagram (PFD) | resource dependent | 21d | 2021-10-17 | 2021-11-06 | 10 FS+42d |  |  | 0d |  | 0.1 | 0.08 | 0.1 |
| 57 |  | Compressor Data Sheet | resource dependent | 21d | 2021-10-24 | 2021-11-13 | 29 FS-14d |  |  | 35d | 0d | 0.0342857142857143 | 0 | 0.04 |
| 59 |  | Process Description | resource dependent | 21d | 2021-10-28 | 2021-11-17 | 34 FS-10d |  |  | 254d | 36d | 0.0266666666666667 | 0 | 0.04 |
| 39 |  | Condensor Data Sheet | resource dependent | 21d | 2021-10-31 | 2021-11-20 | 34 FS-7d, 10 |  |  | 7d | 0d | 0.020952380952381 | 0.024 | 0.04 |
| 42 |  | Economizer Data Sheet | resource dependent | 21d | 2021-10-31 | 2021-11-20 | 34 FS-7d |  |  | 7d | 0d | 0.020952380952381 | 0.024 | 0.04 |
| 71 |  | Thermal Calculation for Heat Exchangers | resource dependent | 21d | 2021-10-31 | 2021-11-20 | 34 FS-7d |  |  | 170d |  | 0.157142857142857 | 0.18 | 0.3 |
| 36 |  | Oil Cooler Data Sheet | resource dependent | 21d | 2021-11-01 | 2021-11-21 | 10, 34 FS-6d |  |  | 6d | 0d | 0.019047619047619 | 0.024 | 0.04 |
| 30 |  | Oil Filter Data Sheet | resource dependent | 21d | 2021-11-07 | 2021-11-27 | 34 |  |  | 0d |  | 0.00761904761904762 | 0 | 0.04 |
| 35 |  | Main Motor Drawing | resource dependent | 21d | 2021-11-07 | 2021-11-27 | 34, 10 |  |  | 0d |  | 0.00952380952380952 | 0 | 0.05 |
| 37 |  | Oil Pump Data Sheet | resource dependent | 21d | 2021-11-07 | 2021-11-27 | 34, 10 |  |  | 0d |  | 0.00761904761904762 | 0 | 0.04 |
| 38 |  | Oil Separator Data Sheet | resource dependent | 21d | 2021-11-07 | 2021-11-27 | 34, 10 |  |  | 0d |  | 0.00761904761904762 | 0 | 0.04 |
| 40 |  | Liquid Receiver Data Sheet | resource dependent | 21d | 2021-11-07 | 2021-11-27 | 34 |  |  | 0d |  | 0.00761904761904762 | 0 | 0.04 |
| 41 |  | K/O Drum Data Sheet | resource dependent | 21d | 2021-11-07 | 2021-11-27 | 34 |  |  | 0d |  | 0.00761904761904762 | 0 | 0.04 |
| 43 |  | Oil Pump Motor Data Sheet | resource dependent | 21d | 2021-11-07 | 2021-11-27 | 34 |  |  | 0d |  | 0.00761904761904762 | 0 | 0.04 |
| 52 |  | Instrument Cable List | resource dependent | 21d | 2021-11-07 | 2021-11-27 | 34, 10 |  |  | 35d |  | 0.00952380952380952 | 0 | 0.05 |
| 61 |  | Instrument Calculations (Safety Relief Valves, Control Valves, Flow Meters, Restriction Orifices, …) | resource dependent | 21d | 2021-11-07 | 2021-11-27 | 34 |  |  | 93d | 26d | 0.00761904761904762 | 0 | 0.04 |
| 64 |  | Filter Dryer Data Sheet | resource dependent | 21d | 2021-11-07 | 2021-11-27 | 34 |  |  | 0d |  | 0.00761904761904762 | 0 | 0.04 |
| 68 |  | PMS for Compressor Package | resource dependent | 21d | 2021-11-07 | 2021-11-27 | 29 |  |  | 209d |  | 0.00761904761904762 | 0 | 0.04 |
| 82 |  | Material Safety Data Sheet | resource dependent | 21d | 2021-11-07 | 2021-11-27 | 34 |  |  | 265d | 21d | 0.00761904761904762 | 0 | 0.04 |
| 84 |  | Evaporator Data Sheet | resource dependent | 21d | 2021-11-07 | 2021-11-27 | 34 |  |  | 0d |  | 0.00761904761904762 | 0.024 | 0.04 |
| 17 |  | Piping and Instrument Diagram (PID) | resource dependent | 30d | 2021-11-12 | 2021-12-11 | 10 FS+68d |  |  | 0d |  | 0 | 0 | 0.1 |
| 73 |  | Capital Spare Part | resource dependent | 21d | 2021-11-14 | 2021-12-04 | 57 |  |  | 279d | 70d | 0 | 0 | 0.04 |
| 74 |  | Special Tools List | resource dependent | 21d | 2021-11-14 | 2021-12-04 | 57 |  |  | 279d | 70d | 0 | 0 | 0.04 |
| 85 |  | Evaporator Drawing | resource dependent | 21d | 2021-11-14 | 2021-12-04 | 84 FS-14d |  |  | 0d |  | 0 | 0 | 0.05 |
| 47 |  | Condensor Drawing | resource dependent | 21d | 2021-11-21 | 2021-12-11 | 39 |  |  | 7d |  | 0 | 0 | 0.05 |
| 50 |  | Economizer Drawing | resource dependent | 21d | 2021-11-21 | 2021-12-11 | 42 |  |  | 7d |  | 0 | 0 | 0.05 |
| 44 |  | Oil Cooler Drawing | resource dependent | 21d | 2021-11-22 | 2021-12-12 | 36 |  |  | 6d |  | 0 | 0 | 0.05 |
| 18 |  | General Arrangement Drawing Including Loads, Displacement, and Maintenace Info | resource dependent | 30d | 2021-11-24 | 2021-12-23 | 17 FS-18d |  |  | 0d |  | 0 | 0 | 0.3 |
| 20 |  | Utility Consumption List | resource dependent | 21d | 2021-11-27 | 2021-12-17 | 34 FS+20d |  |  | 266d | 57d | 0 | 0 | 0.04 |
| 31 |  | Oil Filter Drawing | resource dependent | 21d | 2021-11-28 | 2021-12-18 | 30 |  |  | 0d |  | 0 | 0 | 0.05 |
| 32 |  | Main Motor Data Sheet and Curve | resource dependent | 21d | 2021-11-28 | 2021-12-18 | 34, 35 |  |  | 0d |  | 0 | 0 | 0.04 |
| 45 |  | Oil Pump Drawing | resource dependent | 21d | 2021-11-28 | 2021-12-18 | 37 |  |  | 0d |  | 0 | 0 | 0.05 |
| 46 |  | Oil Separator Drawing | resource dependent | 21d | 2021-11-28 | 2021-12-18 | 38 |  |  | 0d |  | 0 | 0 | 0.05 |
| 48 |  | Liquid Receiver Drawing | resource dependent | 21d | 2021-11-28 | 2021-12-18 | 40 |  |  | 0d |  | 0 | 0 | 0.05 |
| 49 |  | K/O Drum Drawing | resource dependent | 21d | 2021-11-28 | 2021-12-18 | 41 |  |  | 0d |  | 0 | 0 | 0.05 |
| 51 |  | Oil Pump Motor Drawing | resource dependent | 21d | 2021-11-28 | 2021-12-18 | 43 |  |  | 0d |  | 0 | 0 | 0.05 |
| 65 |  | Filter Dryer Drawing | resource dependent | 21d | 2021-11-28 | 2021-12-18 | 64 |  |  | 0d |  | 0 | 0 | 0.05 |
| 19 |  | Mechanical Calculation of Heat Exchangers and Pressure Vessles | resource dependent | 21d | 2021-12-05 | 2021-12-25 | 31 FS-14d, 44 FS-14d, 45 FS-14d, 46 FS-14d, 47 FS-14d, 48 FS-14d, 49 FS-14d, 50 FS-14d, 51 FS-14d, 65 FS-14d, 57 FS-14d, 35 FS-14d, 34, 85 |  |  | 0d |  | 0 | 0 | 0.3 |
| 62 |  | Instrument Hook up Drawings | resource dependent | 21d | 2021-12-10 | 2021-12-30 | 34, 18 FS-14d |  |  | 2d |  | 0 | 0 | 0.04 |
| 79 |  | Standard Support | resource dependent | 21d | 2021-12-10 | 2021-12-30 | 18 FS-14d |  |  | 5d | 0d | 0 | 0 | 0.04 |
| 21 |  | Instrument Index List (Including Alarm & Trip Points) | resource dependent | 21d | 2021-12-12 | 2022-01-01 | 17 |  |  | 23d | 0d | 0 | 0 | 0.04 |
| 23 |  | Control Narrative (Sequence Description) | resource dependent | 21d | 2021-12-12 | 2022-01-01 | 17 |  |  | 209d | 0d | 0 | 0 | 0.04 |
| 53 |  | Instrument Data Sheets | resource dependent | 21d | 2021-12-12 | 2022-01-01 | 19 FS-14d, 17 |  |  | 0d |  | 0 | 0 | 0.04 |
| 54 |  | Cause and Effect Diagram | resource dependent | 21d | 2021-12-12 | 2022-01-01 | 17 |  |  | 107d | 0d | 0 | 0 | 0.04 |
| 60 |  | Outline Dimensional Drawings (Cabinets Arrangement) | resource dependent | 21d | 2021-12-19 | 2022-01-08 | 18 FS-5d, 34 |  |  | 0d |  | 0 | 0 | 0.04 |
| 63 |  | Noise Data Sheet | resource dependent | 21d | 2021-12-19 | 2022-01-08 | 32, 57 |  |  | 244d | 35d | 0 | 0 | 0.04 |
| 76 |  | Motor Operation & Maintenance Manual | resource dependent | 21d | 2021-12-19 | 2022-01-08 | 32 |  |  | 0d |  | 0 | 0 | 0.04 |
| 78 |  | Coupling Drawing | resource dependent | 21d | 2021-12-19 | 2022-01-08 | 32 |  |  | 0d |  | 0 | 0 | 0.04 |
| 24 |  | Spare Parts List for Commissioning & Start-up | resource dependent | 21d | 2021-12-24 | 2022-01-13 | 18 |  |  | 239d | 30d | 0 | 0 | 0.04 |
| 25 |  | Spare Parts List for 2-Year Operation | resource dependent | 21d | 2021-12-24 | 2022-01-13 | 18 |  |  | 239d | 30d | 0 | 0 | 0.04 |
| 26 |  | IOM(including start up, shut down, precommissioning, commissioning procedure) | resource dependent | 21d | 2021-12-24 | 2022-01-13 | 18, 59 |  |  | 218d | 0d | 0 | 0 | 0.04 |
| 58 |  | Equipment List | resource dependent | 21d | 2021-12-24 | 2022-01-13 | 18, 34 |  |  | 239d | 30d | 0 | 0 | 0.04 |
| 66 |  | 3D Model | resource dependent | 21d | 2021-12-24 | 2022-01-13 | 18 |  |  | 6d | 0d | 0 | 0 | 0.04 |

Notes:
- 222: Expenses: Finish - (cost) 0
- 3: Expenses: LOI Date - (cost) 0
- 4: Expenses: Effective Date - (cost) 0
- 5: Expenses: K.O.M - (cost) 0
- 6: Expenses: Bank Garanty Payment Date - (cost) 0
- 7: Expenses: Advanced Payment Date - (cost) 0

| ID | WBS | Activity | Type | Duration | Start | Finish | Predecessors | Planned start | Planned finish | Total float | Free float | % WF | % Plan for Report | % Actual for Report |
| --- | --- | --- | --- | --- | --- | --- | --- | --- | --- | --- | --- | --- | --- | --- |
| 70 |  | MTO of Insulation | resource dependent | 21d | 2021-12-24 | 2022-01-13 | 18, 10 |  |  | 12d | 7d | 0.04 | 0 | 0 |
| 72 |  | Name Plate Drawing | resource dependent | 21d | 2021-12-24 | 2022-01-13 | 18 |  |  | 256d |  | 0.04 | 0 | 0 |
| 81 |  | Stress Analysis Report | resource dependent | 21d | 2021-12-24 | 2022-01-13 | 61, 18 |  |  | 239d | 30d | 0.04 | 0 | 0 |
| 80 |  | Support List | resource dependent | 21d | 2021-12-31 | 2022-01-20 | 79 |  |  | 5d | 0d | 0.04 | 0 | 0 |
| 22 |  | Junction Box Connection Diagrams (Including Wire Schematic to Instruments) | resource dependent | 21d | 2022-01-02 | 2022-01-22 | 21, 18 |  |  | 23d | 0d | 0.04 | 0 | 0 |
| 27 |  | I/O List | resource dependent | 21d | 2022-01-02 | 2022-01-22 | 23, 17 |  |  | 230d | 21d | 0.04 | 0 | 0 |
| 28 |  | Logic Diagram (Print out PLC Program) | resource dependent | 21d | 2022-01-02 | 2022-01-22 | 34, 23 |  |  | 209d | 0d | 0.04 | 0 | 0 |
| 33 |  | PLC Wiring Diagrams | resource dependent | 21d | 2022-01-02 | 2022-01-22 | 54 |  |  | 107d | 21d | 0.04 | 0 | 0 |
| 77 |  | ON/OFF Valve Data Sheet | resource dependent | 21d | 2022-01-02 | 2022-01-22 | 53 |  |  | 230d | 21d | 0.04 | 0 | 0 |
| 83 |  | PSV Data Sheet | resource dependent | 21d | 2022-01-02 | 2022-01-22 | 53 |  |  | 162d | 0d | 0.04 | 0 | 0 |
| 55 |  | Operating Manual (Including Start up, Shut Down, Pre-Commissioning, Commissioning Procedure) | resource dependent | 21d | 2022-01-14 | 2022-02-03 | 26 |  |  | 218d | 9d | 0.04 | 0 | 0 |
| 67 |  | Line List | resource dependent | 21d | 2022-01-14 | 2022-02-03 | 17, 66 |  |  | 218d | 9d | 0.04 | 0 | 0 |
| 69 |  | Isometrci Drawing for Interconnecting Piping | resource dependent | 21d | 2022-01-14 | 2022-02-03 | 66, 18 |  |  | 6d | 0d | 0.04 | 0 | 0 |
| 56 |  | Operating / Control Philosophy | resource dependent | 21d | 2022-01-23 | 2022-02-12 | 28, 17 |  |  | 209d | 0d | 0.04 | 0 | 0 |
| 75 |  | LCS Wiring and Drawing | resource dependent | 21d | 2022-01-23 | 2022-02-12 | 22, 34 |  |  | 86d | 0d | 0.04 | 0 | 0 |
| 16 |  | Vendor Final Book Index | resource dependent | 21d | 2022-02-13 | 2022-03-05 | 13, 14, 20, 27, 54, 55, 56, 58, 67, 91, 101, 100, 24, 25, 73, 74, 63, 98, 77, 81 |  |  | 209d |  | 0.1 | 0 | 0 |
|  | 3 | **QC DOCUMENT** |  |  | 2021-10-18 | 2022-01-28 |  |  |  |  |  |  |  |  |
| 87 |  | Inspection & Test Plan (ITP) (for Whole Package) | resource dependent | 0d | 2021-10-18 | 2021-11-07 | 11 FS+2d | 2021-10-18 | 2021-10-18 | 178d | 0d | 0.1 | 0.1 | 0.06 |
| 100 |  | Lifting Procedure | resource dependent | 21d | 2021-11-28 | 2021-12-18 | 87 FS+20d |  |  | 265d | 56d | 0.04 | 0 | 0 |
| 101 |  | Certificates (Including Welder Qualification Certificate / NDT Personnel Qualification Certificate, etc.) | resource dependent | 21d | 2021-11-28 | 2021-12-18 | 87 FS+20d |  |  | 265d | 56d | 0.04 | 0 | 0 |
| 88 |  | Welding Book (WPS, PQR and Welding / NDE Map) | resource dependent | 21d | 2021-11-28 | 2021-12-18 | 87 FS+20d |  |  | 178d | 70d | 0.04 | 0 | 0 |
| 89 |  | Painting Procedure | resource dependent | 21d | 2021-11-28 | 2021-12-18 | 87 FS+20d |  |  | 272d |  | 0.04 | 0 | 0 |
| 90 |  | Packing, Marking and Shipping Procedure | resource dependent | 21d | 2021-11-28 | 2021-12-18 | 87 FS+20d |  |  | 282d |  | 0.04 | 0 | 0 |
| 91 |  | Fat Procedure for Control System | resource dependent | 21d | 2021-11-28 | 2021-12-18 | 87 FS+20d |  |  | 265d | 56d | 0.04 | 0 | 0 |
| 92 |  | NDE Procedure | resource dependent | 21d | 2021-11-28 | 2021-12-18 | 87 FS+20d |  |  | 227d | 90d | 0.04 | 0 | 0 |
| 93 |  | PMI Procedure | resource dependent | 21d | 2021-11-28 | 2021-12-18 | 87 FS+20d |  |  | 244d | 0d | 0.04 | 0 | 0 |
| 94 |  | Inspection Notification | resource dependent | 21d | 2021-11-28 | 2021-12-18 | 87 FS+20d |  |  | 275d |  | 0.02 | 0 | 0 |
| 95 |  | Inspection and Test Plan for Compressor | resource dependent | 21d | 2021-11-28 | 2021-12-18 | 87 FS+20d |  |  | 207d | 0d | 0.02 | 0 | 0.012 |
| 97 |  | Inspection and Test Procedure for Vessle Skids | resource dependent | 21d | 2021-11-28 | 2021-12-18 | 87 FS+20d |  |  | 227d | 90d | 0.04 | 0 | 0 |
| 99 |  | Hydrostatic Test Procedure | resource dependent | 21d | 2021-11-28 | 2021-12-18 | 87 FS+20d |  |  | 232d | 224d | 0.04 | 0 | 0 |
| 98 |  | Preservation Procedure | resource dependent | 21d | 2021-12-19 | 2022-01-08 | 93, 87, 82 |  |  | 244d | 35d | 0.04 | 0 | 0 |
| 96 |  | Inspection and Test Procedure for Compressor | resource dependent | 21d | 2022-01-08 | 2022-01-28 | 95 FS+20d |  |  | 207d |  | 0.02 | 0 | 0.012 |

| ID | WBS | Activity | Type | Duration | Start | Finish | Predecessors | Total float | Free float | % WF | % Plan for Report | % Actual for Report |
| --- | --- | --- | --- | --- | --- | --- | --- | --- | --- | --- | --- | --- |
|  | 3 | **Supply of Material** |  |  | 2021-11-14 | 2022-07-17 |  |  |  |  |  |  |
|  | 1 | **ForeignSupply** |  |  | 2021-11-14 | 2022-07-17 |  |  |  |  |  |  |
|  | 1 | **Special Valves** |  |  | 2022-01-02 | 2022-06-15 |  |  |  |  |  |  |
| 105 |  | PO placement (Other Valves) | resource dependent | 10d | 2022-01-02 | 2022-01-11 | 53, 61 | 58d | 0d | 0.17 | 0 | 0 |
| 106 |  | EX Work (Other Valves) | resource dependent | 120d | 2022-01-12 | 2022-05-11 | 105 | 58d | 0d | 0.68 | 0 | 0 |
| 107 |  | Custom clearance (Other Valves) | resource dependent | 30d | 2022-05-12 | 2022-06-10 | 106 | 58d | 0d | 0.51 | 0 | 0 |
| 108 |  | Delivery to shop (Other Valves) | resource dependent | 5d | 2022-06-11 | 2022-06-15 | 107 | 58d |  | 0.34 | 0 | 0 |
|  | 2 | **Instrument** |  |  | 2022-01-02 | 2022-04-16 |  |  |  |  |  |  |
| 110 |  | PO placement (Instrument) | resource dependent | 10d | 2022-01-02 | 2022-01-11 | 53, 52, 62 | 0d |  | 0.17 | 0 | 0 |
| 111 |  | EX Work (Instrument) | resource dependent | 60d | 2022-01-12 | 2022-03-12 | 110 | 0d |  | 0.68 | 0 | 0 |
| 112 |  | Custom clearance (Instrument) | resource dependent | 30d | 2022-03-13 | 2022-04-11 | 111 | 0d |  | 0.51 | 0 | 0 |
| 113 |  | Delivery to shop (Instrument) | resource dependent | 5d | 2022-04-12 | 2022-04-16 | 112 | 0d |  | 0.34 | 0 | 0 |
|  | 3 | **Electrical (Electro motor)** |  |  | 2022-01-09 | 2022-07-17 |  |  |  |  |  |  |
| 115 |  | PO placement (Electrical (Electro motor)) | resource dependent | 10d | 2022-01-09 | 2022-01-18 | 32, 34, 35, 60, 76, 78 | 0d |  | 0.5 | 0 | 0 |
| 116 |  | EX Work (Electrical (Electro motor)) | resource dependent | 150d | 2022-01-19 | 2022-06-17 | 115 | 0d |  | 2 | 0 | 0 |
| 117 |  | Custom clearance (Electrical (Electro motor)) | resource dependent | 25d | 2022-06-18 | 2022-07-12 | 116 | 0d |  | 1.5 | 0 | 0 |
| 118 |  | Delivery to shop (Electrical (Electro motor)) | resource dependent | 5d | 2022-07-13 | 2022-07-17 | 117 | 0d |  | 1 | 0 | 0 |
|  | 4 | **Filter** |  |  | 2021-12-19 | 2022-04-02 |  |  |  |  |  |  |
| 120 |  | PO placement (Filter) | resource dependent | 10d | 2021-12-19 | 2021-12-28 | 65, 31 | 132d | 0d | 0.17 | 0 | 0 |
| 121 |  | EX Work (Filter) | resource dependent | 60d | 2021-12-29 | 2022-02-26 | 120 | 132d | 0d | 0.68 | 0 | 0 |
| 122 |  | Custom clearance (Filter) | resource dependent | 30d | 2022-02-27 | 2022-03-28 | 121 | 132d | 0d | 0.51 | 0 | 0 |
| 123 |  | Delivery to shop (Filter) | resource dependent | 5d | 2022-03-29 | 2022-04-02 | 122 | 132d |  | 0.34 | 0 | 0 |
|  | 5 | **Oil pump & Oil separator** |  |  | 2021-12-19 | 2022-06-16 |  |  |  |  |  |  |
| 125 |  | PO placement (Oil pump & Oil separator) | resource dependent | 10d | 2021-12-19 | 2021-12-28 | 45, 46, 44, 51 | 8d | 0d | 0.17 | 0 | 0 |
| 126 |  | EX Work (Oil pump & Oil separator) | resource dependent | 140d | 2021-12-29 | 2022-05-17 | 125 | 8d | 0d | 0.68 | 0 | 0 |
| 127 |  | Custom clearance (Oil pump & Oil separator) | resource dependent | 25d | 2022-05-18 | 2022-06-11 | 126 | 8d | 0d | 0.51 | 0 | 0 |
| 128 |  | Delivery to shop (Oil pump & Oil separator) | resource dependent | 5d | 2022-06-12 | 2022-06-16 | 127 | 8d | 0d | 0.34 | 0 | 0 |

| ID | WBS | Activity | Type | Duration | Start | Finish | Predecessors | Total float | Free float | % WF | % Plan for Report | % Actual for Report |
| --- | --- | --- | --- | --- | --- | --- | --- | --- | --- | --- | --- | --- |
|  | 6 | **Compressor** |  |  | 2021-11-14 | 2022-05-17 |  |  |  |  |  |  |
| 130 |  | PO placement (Compressor) | resource dependent | 10d | 2021-11-14 | 2021-11-23 | 34, 57 | 38d | 0d | 1.25 | 0 | 0 |
| 131 |  | EX Work (Compressor) | resource dependent | 140d | 2021-11-24 | 2022-04-12 | 130 | 38d | 0d | 5 | 0 | 0 |
| 132 |  | Custom clearance (Compressor) | resource dependent | 30d | 2022-04-13 | 2022-05-12 | 131 | 38d | 0d | 3.75 | 0 | 0 |
| 133 |  | Delivery to shop (Compressor) | resource dependent | 5d | 2022-05-13 | 2022-05-17 | 132 | 38d |  | 2.5 | 0 | 0 |
|  | 7 | **Other material** |  |  | 2021-12-24 | 2022-06-06 |  |  |  |  |  |  |
| 135 |  | PO placement (other material) | resource dependent | 10d | 2021-12-24 | 2022-01-02 | 18 | 12d | 0d | 0.07 | 0 | 0 |
| 136 |  | EX Work (Other material) | resource dependent | 120d | 2022-01-03 | 2022-05-02 | 135 | 12d | 0d | 0.28 | 0 | 0 |
| 137 |  | Custom clearance (Other material) | resource dependent | 30d | 2022-05-03 | 2022-06-01 | 136 | 12d | 0d | 0.21 | 0 | 0 |
| 138 |  | Delivery to shop (Other material) | resource dependent | 5d | 2022-06-02 | 2022-06-06 | 137 | 12d | 4d | 0.14 | 0 | 0 |
|  | 2 | **Domestic Supply** |  |  | 2021-12-24 | 2022-03-24 |  |  |  |  |  |  |
|  | 1 | **Pipe** |  |  | 2022-02-04 | 2022-02-28 |  |  |  |  |  |  |
| 141 |  | PO placement (Pipe) | resource dependent | 5d | 2022-02-04 | 2022-02-08 | 18, 17, 69 | 6d | 0d | 0.1 | 0 | 0 |
| 142 |  | EX Work (Pipe) | resource dependent | 15d | 2022-02-09 | 2022-02-23 | 141 | 6d | 0d | 0.4 | 0 | 0 |
| 143 |  | Delivery to shop (Pipe) | resource dependent | 5d | 2022-02-24 | 2022-02-28 | 142 | 6d | 1d | 0.5 | 0 | 0 |
|  | 2 | **Plate** |  |  | 2021-12-24 | 2022-01-17 |  |  |  |  |  |  |
| 145 |  | PO placement (Plate) | resource dependent | 5d | 2021-12-24 | 2021-12-28 | 18 | 48d | 0d | 0.1 | 0 | 0 |
| 146 |  | EX Work (Plate) | resource dependent | 15d | 2021-12-29 | 2022-01-12 | 145 | 48d | 0d | 0.4 | 0 | 0 |
| 147 |  | Delivery to shop (Plate) | resource dependent | 5d | 2022-01-13 | 2022-01-17 | 146 | 48d | 0d | 0.5 | 0 | 0 |
|  | 3 | **Flange & Fitting** |  |  | 2021-12-24 | 2022-01-17 |  |  |  |  |  |  |
| 149 |  | PO placement (Flange & Fitting) | resource dependent | 5d | 2021-12-24 | 2021-12-28 | 18 | 48d | 0d | 0.1 | 0 | 0 |
| 150 |  | EX Work (Flange & Fitting) | resource dependent | 15d | 2021-12-29 | 2022-01-12 | 149 | 48d | 0d | 0.4 | 0 | 0 |
| 151 |  | Delivery to shop (Flange & Fitting) | resource dependent | 5d | 2022-01-13 | 2022-01-17 | 150 | 48d | 43d | 0.5 | 0 | 0 |
|  | 4 | **Gasket** |  |  | 2021-12-24 | 2022-01-17 |  |  |  |  |  |  |
| 153 |  | PO placement (Gasket) | resource dependent | 5d | 2021-12-24 | 2021-12-28 | 18 | 48d | 0d | 0.1 | 0 | 0 |
| 154 |  | EX Work (Gasket) | resource dependent | 15d | 2021-12-29 | 2022-01-12 | 153 | 48d | 0d | 0.4 | 0 | 0 |
| 155 |  | Delivery to shop (Gasket) | resource dependent | 5d | 2022-01-13 | 2022-01-17 | 154 | 48d | 43d | 0.5 | 0 | 0 |

| ID | WBS | Activity | Type | Duration | Start | Finish | Predecessors | Total float | Free float | % WF | % Plan for Report | % Actual for Report |
| --- | --- | --- | --- | --- | --- | --- | --- | --- | --- | --- | --- | --- |
|  | 5 | **Bolt & Nut** |  |  | 2021-12-24 | 2022-01-17 |  |  |  |  |  |  |
| 157 |  | PO placement (Bolt & Nut) | resource dependent | 5d | 2021-12-24 | 2021-12-28 | 18 | 207d | 0d | 0.1 | 0 | 0 |
| 158 |  | EX Work (Bolt & Nut) | resource dependent | 15d | 2021-12-29 | 2022-01-12 | 157 | 207d | 0d | 0.4 | 0 | 0 |
| 159 |  | Delivery to shop (Bolt & Nut) | resource dependent | 5d | 2022-01-13 | 2022-01-17 | 158 | 207d |  | 0.5 | 0 | 0 |
|  | 6 | **Electrical** |  |  | 2022-01-23 | 2022-03-03 |  |  |  |  |  |  |
| 161 |  | PO placement (Electrical) | resource dependent | 5d | 2022-01-23 | 2022-01-27 | 18, 22 | 23d | 0d | 0.1 | 0 | 0 |
| 162 |  | EX Work (Electrical) | resource dependent | 30d | 2022-01-28 | 2022-02-26 | 161 | 23d | 0d | 0.4 | 0 | 0 |
| 163 |  | Delivery to shop (Electrical) | resource dependent | 5d | 2022-02-27 | 2022-03-03 | 162 | 23d |  | 0.5 | 0 | 0 |
|  | 7 | **Manual valves** |  |  | 2022-01-23 | 2022-03-03 |  |  |  |  |  |  |
| 165 |  | PO placement (Manual valves) | resource dependent | 5d | 2022-01-23 | 2022-01-27 | 18, 61, 83 | 162d | 0d | 0.1 | 0 | 0 |
| 166 |  | EX Work (Manual valves) | resource dependent | 30d | 2022-01-28 | 2022-02-26 | 165 | 162d | 0d | 0.4 | 0 | 0 |
| 167 |  | Delivery to shop (Manual valves) | resource dependent | 5d | 2022-02-27 | 2022-03-03 | 166 | 162d |  | 0.5 | 0 | 0 |
|  | 8 | **Instrument** |  |  | 2022-01-02 | 2022-02-10 |  |  |  |  |  |  |
| 169 |  | PO placement (Domestic Instrument) | resource dependent | 5d | 2022-01-02 | 2022-01-06 | 53, 18 | 24d | 0d | 0.1 | 0 | 0 |
| 170 |  | EX Work (Domestic Instrument) | resource dependent | 30d | 2022-01-07 | 2022-02-05 | 169 | 24d | 0d | 0.4 | 0 | 0 |
| 171 |  | Delivery to shop (Domestic Instrument) | resource dependent | 5d | 2022-02-06 | 2022-02-10 | 170 | 24d | 19d | 0.5 | 0 | 0 |
|  | 9 | **PLC** |  |  | 2022-02-13 | 2022-03-24 |  |  |  |  |  |  |
| 173 |  | PO placement (PLC) | resource dependent | 5d | 2022-02-13 | 2022-02-17 | 33, 18, 75 | 86d | 0d | 0.1 | 0 | 0 |
| 174 |  | EX Work (PLC) | resource dependent | 30d | 2022-02-18 | 2022-03-19 | 173 | 86d | 0d | 0.4 | 0 | 0 |
| 175 |  | Delivery to shop (PLC) | resource dependent | 5d | 2022-03-20 | 2022-03-24 | 174 | 86d | 78d | 0.5 | 0 | 0 |
|  | 10 | **Other material** |  |  | 2022-01-21 | 2022-03-01 |  |  |  |  |  |  |
| 177 |  | PO placement (Other material (Domestic) ) | resource dependent | 5d | 2022-01-21 | 2022-01-25 | 18, 70, 80 | 5d | 0d | 0.1 | 0 | 0 |
| 178 |  | EX Work (Other material(Domestic)) | resource dependent | 30d | 2022-01-26 | 2022-02-24 | 177 | 5d | 0d | 0.4 | 0 | 0 |
| 179 |  | Delivery to shop (Other material(Domestic)) | resource dependent | 5d | 2022-02-25 | 2022-03-01 | 178 | 5d | 0d | 0.5 | 0 | 0 |

| ID | WBS | Activity | Type | Duration | Start | Finish | Predecessors | Planned start | Planned finish | Total float | Free float | % WF | % Plan for Report | % Actual for Report |
| --- | --- | --- | --- | --- | --- | --- | --- | --- | --- | --- | --- | --- | --- | --- |
|  | 4 | **Fabrication** |  |  | 2022-01-18 | 2022-09-26 |  |  |  |  |  |  |  |  |
| 214 |  | Visual & DIM. Inspection | resource dependent | 3d | 2022-09-14 | 2022-09-16 | 213 |  |  | 0d |  | 4 | 0 | 0 |
| 215 |  | Surface Preparation | resource dependent | 3d | 2022-09-17 | 2022-09-19 | 214, 89 |  |  | 0d |  | 2.5 | 0 | 0 |
| 216 |  | Painting | resource dependent | 5d | 2022-09-20 | 2022-09-24 | 215, 89, 94 |  |  | 0d |  | 2.5 | 0 | 0 |
| 217 |  | Final Check | resource dependent | 2d | 2022-09-25 | 2022-09-26 | 216 |  |  | 0d |  | 3 | 0 | 0 |
|  | 1 | **Fabrication For Compressor unit** |  |  | 2022-03-02 | 2022-08-28 |  |  |  |  |  |  |  |  |
| 183 |  | Oil filter | resource dependent | 130d | 2022-03-02 | 2022-07-09 | 143, 147, 151, 155, 179, 171 |  |  | 5d |  | 0.33 | 0 | 0 |
| 184 |  | Oil cooler | resource dependent | 130d | 2022-03-02 | 2022-07-09 | 143, 147, 151, 155, 179, 171 |  |  | 5d |  | 0.99 | 0 | 0 |
| 185 |  | Filter dryer | resource dependent | 130d | 2022-03-02 | 2022-07-09 | 143, 147, 151, 155, 179, 171 |  |  | 5d |  | 0.33 | 0 | 0 |
| 182 |  | Compressor unit Fabrication | resource dependent | 20d | 2022-06-25 | 2022-07-14 | 133, 128, 118 FS-23d, 113, 171, 68 |  |  | 0d |  | 1.36 | 0 | 0 |
| 186 |  | Part Assembly | resource dependent | 20d | 2022-07-15 | 2022-08-03 | 183, 184, 185, 182 |  |  | 0d |  | 1.35 | 0 | 0 |
| 187 |  | Part Welding | resource dependent | 20d | 2022-08-04 | 2022-08-23 | 186, 88 |  |  | 0d |  | 0.82 | 0 | 0 |
| 188 |  | Running test | resource dependent | 5d | 2022-08-24 | 2022-08-28 | 187, 96 |  |  | 0d |  | 0.82 | 0 | 0 |
|  | 2 | **Fabrication For Condensor** |  |  | 2022-03-27 | 2022-08-12 |  |  |  |  |  |  |  |  |
| 190 |  | Part Fabrication-(cutting,rolling,casting) | resource dependent | 30d | 2022-03-27 | 2022-04-25 | 143, 147, 151, 155, 163, 171, 113 FS-21d, 47 |  |  | 0d |  | 3.31 | 0 | 0 |
| 191 |  | Part Assembly | resource dependent | 50d | 2022-04-26 | 2022-06-14 | 190 |  |  | 0d |  | 1.05 | 0 | 0 |
| 192 |  | Part Welding | resource dependent | 25d | 2022-06-15 | 2022-08-09 | 191, 88 | 2022-06-15 | 2022-07-09 | 0d |  | 0.82 | 0 | 0 |
| 193 |  | NDT Condensor | resource dependent | 3d | 2022-08-10 | 2022-08-12 | 192, 92 |  |  | 0d |  | 0.82 | 0 | 0 |
|  | 3 | **Fabrication For Hexane chiller** |  |  | 2022-03-31 | 2022-08-12 |  |  |  |  |  |  |  |  |
| 195 |  | Part Fabrication-(cutting,rolling,casting) | resource dependent | 40d | 2022-03-31 | 2022-05-09 | 143, 147, 151, 155, 163, 171, 113 FS-17d |  |  | 0d |  | 3.31 | 0 | 0 |
| 196 |  | Part Assembly | resource dependent | 65d | 2022-05-10 | 2022-07-13 | 195, 71 |  |  | 0d |  | 1.05 | 0 | 0 |
| 197 |  | Part Welding | resource dependent | 25d | 2022-07-14 | 2022-08-07 | 196, 88 |  |  | 0d |  | 0.82 | 0 | 0 |
| 198 |  | NDT Hexane chiller | resource dependent | 5d | 2022-08-08 | 2022-08-12 | 197, 92 |  |  | 0d |  | 0.82 | 0 | 0 |
|  | 4 | **Fabrication For Skid** |  |  | 2022-01-18 | 2022-03-28 |  |  |  |  |  |  |  |  |
| 200 |  | Part Fabrication-(cutting,rolling,casting) | resource dependent | 20d | 2022-01-18 | 2022-02-06 | 147 |  |  | 137d | 0d | 3.31 | 0 | 0 |
| 201 |  | Part Assembly | resource dependent | 20d | 2022-02-07 | 2022-02-26 | 200 |  |  | 137d | 0d | 1.05 | 0 | 0 |
| 202 |  | Part Welding | resource dependent | 20d | 2022-02-27 | 2022-03-18 | 201, 88 |  |  | 137d | 0d | 0.82 | 0 | 0 |
| 203 |  | NDT Skid | resource dependent | 10d | 2022-03-19 | 2022-03-28 | 202, 92, 97 |  |  | 137d |  | 0.82 | 0 | 0 |

| ID | WBS | Activity | Type | Duration | Start | Finish | Predecessors | Total float | Free float | % WF | % Plan for Report | % Actual for Report |
| --- | --- | --- | --- | --- | --- | --- | --- | --- | --- | --- | --- | --- |
|  | 5 | **Fabrication For Other** |  |  | 2022-06-11 | 2022-08-04 |  |  |  |  |  |  |
| 205 |  | Part Fabrication-(cutting,rolling,casting) | resource dependent | 20d | 2022-06-11 | 2022-06-30 | 143, 147, 151, 155, 179, 163, 171, 175, 128 FS-6d, 138 | 8d | 0d | 1.75 | 0 | 0 |
| 206 |  | Part Assembly | resource dependent | 15d | 2022-07-01 | 2022-07-15 | 205 | 8d | 0d | 0.75 | 0 | 0 |
| 207 |  | Part Welding | resource dependent | 15d | 2022-07-16 | 2022-07-30 | 206, 88 | 8d | 0d | 0.25 | 0 | 0 |
| 208 |  | Hydro test | resource dependent | 5d | 2022-07-31 | 2022-08-04 | 207, 99 | 8d |  | 0.25 | 0 | 0 |
|  | 6 | **Assembly of packages on skid** |  |  | 2022-08-13 | 2022-09-13 |  |  |  |  |  |  |
| 210 |  | Inter connecting piping | resource dependent | 15d | 2022-08-13 | 2022-08-27 | 188 FS-16d, 193, 198, 203, 167, 108, 123, 159, 208 | 0d |  | 3.31 | 0 | 0 |
| 211 |  | Part Assembly | resource dependent | 5d | 2022-08-28 | 2022-09-01 | 210 | 0d |  | 1.05 | 0 | 0 |
| 212 |  | Part Welding | resource dependent | 7d | 2022-09-02 | 2022-09-08 | 211, 88 | 0d |  | 0.82 | 0 | 0 |
| 213 |  | NDT packages on skid | resource dependent | 5d | 2022-09-09 | 2022-09-13 | 212, 92 | 0d |  | 0.82 | 0 | 0 |
|  | 5 | **FINAL INSPECTION TEST and RELEASE NOTE for Ex-Work** |  |  | 2022-09-27 | 2022-09-30 |  |  |  |  |  |  |
| 219 |  | FINAL INSPECTION TEST and RELEASE NOTE for Ex-Work | resource dependent | 4d | 2022-09-27 | 2022-09-30 | 217, 90, 72 | 0d |  | 10 | 0 | 0 |
|  | 6 | **Final Data Book** |  |  | 2022-10-01 | 2022-10-04 |  |  |  |  |  |  |
| 221 |  | VENDOR FINAL DATA BOOK | resource dependent | 4d | 2022-10-01 | 2022-10-04 | 219, 16 | 0d |  | 5 | 0 | 0 |
